# Jerry SW Feature Planning 2006-02-15

Schedule from MS Project, 2006-02-20 to 2006-07-31.
CMM

## Calendars

- Standard: Mon-Fri 08:00-12:00, 13:00-17:00; Sat-Sun off.

## Resources

| Resource |
| --- |
| SISL |
| SISL 1 |
| SISL 2 |
| SISL1 |
| SISL 3 |
| BJ 1 |
| BJ 2 |
| BJ 3 |
| SISL 4 |
| SISL 5 |
| SISL 6 |
| SISL 7 |
| SISL 8 |
| SISL 9 |
| SISL 10 |
| SISL 11 |
| SISL 12 |
| SISL 13 |
| SISL 14 |
| SISL 15 |
| SISL 16 |
| SISL 17 |
| SISL 18 |
| PSE NJ 1 |
| PSE NJ 2 |
| SISL 20 |
| SISL 19 |

## Schedule

| ID | WBS | Task | Type | Duration | Start | Finish | Predecessors | Total slack | Free slack | Constraint | Resources | Work |
| --- | --- | --- | --- | --- | --- | --- | --- | --- | --- | --- | --- | --- |
| 1 | 1 | **Preconditions** |  | 25d | 2006-02-20 | 2006-03-24 |  | 34d |  |  |  | 160h |
| 2 | 1.1 | Identify all text and icon resources for sprint 1 and sprint 2 |  | 2w | 2006-02-20 | 2006-03-03 |  | 50d | 0d | start no earlier than 2006-02-20 | SISL 4 | 80h |
| 3 | 1.2 | Identify all text and icon resources for other sprints |  | 2w | 2006-03-06 | 2006-03-17 | 2 | 50d | 0d | start no earlier than 2006-02-20 | SISL 4 | 80h |
| 4 | 1.3 | Integration of Sprint 1 and 2 texts/icon resources into database |  | 2w | 2006-02-27 | 2006-03-10 |  | 55d | 0d | start no earlier than 2006-02-27 |  |  |
| 5 | 1.4 | Integration of remaining texts/icon resources into database |  | 2w | 2006-03-13 | 2006-03-24 | 4 | 65d |  |  |  |  |
| 6 | 1.5 | define Font in UIOS |  | 1w | 2006-02-20 | 2006-02-24 |  | 85d |  | start no earlier than 2006-02-20 |  |  |
| 7 | 1.6 | color scheme switch in UIOS |  | 2w | 2006-02-20 | 2006-03-03 |  | 40d | 0d | start no earlier than 2006-02-20 |  |  |
| 8 | 1.7 | external interfaces from other components, e.g. IDC |  | 3w | 2006-02-20 | 2006-03-10 |  | 65d | 0d | start no earlier than 2006-02-20 |  |  |
| 9 | 1.8 | DB setup |  | 0.4w | 2006-02-20 | 2006-02-21 |  | 84d | 0d | finish no earlier than 2006-02-21 |  |  |
| 11 | 2 | **SW Milestone** |  | 86d | 2006-03-31 | 2006-07-31 |  | 0d |  |  |  |  |
| 12 | 2.1 | Sprint 1 SW Demo | milestone | 0w | 2006-03-31 | 2006-03-31 | 44 | 86d |  |  |  |  |
| 13 | 2.2 | Sprint 2 SW Demo | milestone | 0w | 2006-04-28 | 2006-04-28 | 85 | 66d |  |  |  |  |
| 14 | 2.3 | Sprint 3 SW Demo | milestone | 0w | 2006-05-31 | 2006-05-31 | 125 | 43d |  |  |  |  |
| 15 | 2.4 | Sprint 4 SW Demo | milestone | 0w | 2006-07-07 | 2006-07-07 | 156 | 16d |  |  |  |  |
| 16 | 2.5 | S25 SW | milestone | 0w | 2006-07-07 | 2006-07-07 | 156 | 16d |  | start no earlier than 2006-07-07 |  |  |
| 17 | 2.6 | S3 SW | milestone | 0w | 2006-07-31 | 2006-07-31 | 16, 157 | 0d |  | must finish on 2006-07-31 |  |  |
| 18 | 2.7 | VF test phaseA start | milestone | 0w | 2006-07-31 | 2006-07-31 | 17 | -1d | 0d | must start on 2006-07-31 |  |  |
| 19 | 3 | **Jerry SW Feature Planning** |  | 113d? | 2006-02-22 | 2006-07-28 |  | 1d |  |  |  | 8200h |
| 20 | 3.1 | **Feature Sprint 1** |  | 28d? | 2006-02-22 | 2006-03-31 |  | 34d |  |  |  | 3280h |
| 21 | 3.1.1 | **pc simu setup** |  | 20d | 2006-02-22 | 2006-03-21 |  | 84d |  |  |  | 240h |
| 22 | 3.1.1.1 | 3 hard keys simulation including blinking effect for Home key |  | 4w | 2006-02-22 | 2006-03-21 | 9 | 94d |  | start no earlier than 2006-02-20 | SISL 1 | 160h |
| 23 | 3.1.1.2 | side keys simulation |  | 2w | 2006-02-22 | 2006-03-07 | 9 | 84d | 8d | start no earlier than 2006-02-22 | SISL 1 | 80h |
| 24 | 3.1.2 | **Start-up/power on dialogs** |  | 20d | 2006-02-22 | 2006-03-21 |  | 94d |  |  |  | 320h |
| 25 | 3.1.2.1 | PIN input including error handling |  | 4w | 2006-02-22 | 2006-03-21 | 9 | 94d |  | start no earlier than 2006-02-22 | SISL 5; SISL 6 | 320h |

Notes:
- 22: Simulation of 3 hard keys (Home, Contacts, Menu). Also, the blinking effect for the Home key.
- 23: Volume up/down side key, Ringer side key and keypad lock side key.
- 24: pin iput, incl. error handling

| ID | WBS | Task | Type | Duration | Start | Finish | Predecessors | Total slack | Free slack | Constraint | Resources | Work |
| --- | --- | --- | --- | --- | --- | --- | --- | --- | --- | --- | --- | --- |
| 26 | 3.1.3 | **Idle screen** |  | 20d | 2006-02-22 | 2006-03-21 |  | 94d |  |  |  | 320h |
| 27 | 3.1.3.1 | Idle screen basic layout |  | 4w | 2006-02-22 | 2006-03-21 | 9 | 94d |  |  | SISL 3; SISL 2 | 320h |
| 28 | 3.1.4 | Home/Contact/Menu hard key invocation |  | 4w | 2006-02-22 | 2006-03-21 | 9 | 94d |  |  | SISL 7 | 160h |
| 29 | 3.1.5 | **Phone spaces, color schemes, Icons, Fonts** |  | 10d | 2006-03-06 | 2006-03-17 |  | 96d |  |  |  | 160h |
| 30 | 3.1.5.1 | color scheme switching interface, define additional virtual colors |  | 2w | 2006-03-06 | 2006-03-17 | 7 | 96d |  |  | BJ 1 | 80h |
| 31 | 3.1.5.2 | text resource define color scheme |  | 1w | 2006-03-06 | 2006-03-10 | 7 | 101d |  |  | BJ 2 | 40h |
| 32 | 3.1.5.3 | phone space color scheme switching(IDC) |  | 1w | 2006-03-13 | 2006-03-17 | 7 | 96d |  | start no earlier than 2006-03-13 | SISL 8 | 40h |
| 33 | 3.1.6 | **Voice call screen basic** |  | 20d | 2006-02-22 | 2006-03-21 |  | 94d |  |  |  | 480h |
| 34 | 3.1.6.1 | call origination, termination, call setup |  | 4w | 2006-02-22 | 2006-03-21 | 9 | 94d |  | start no earlier than 2006-02-20 | SISL 8; SISL 9; SISL 10 | 480h |
| 35 | 3.1.7 | Headline and soft key look and feel |  | 4w | 2006-02-22 | 2006-03-21 | 9 | 94d |  | start no earlier than 2006-02-20 | SISL 11; SISL 12; SISL 13 | 480h |
| 36 | 3.1.8 | **Menu look and feel basic** |  | 20d | 2006-02-22 | 2006-03-21 |  | 34d |  |  | BJ 1; BJ 2 | 720h |
| 37 | 3.1.8.1 | look and feel w/o transition |  | 4w | 2006-02-22 | 2006-03-21 | 9 | 34d | 0d | start no earlier than 2006-02-20 | BJ 1; BJ 2 | 320h |
| 38 | 3.1.8.2 | scroll bar |  | 2w | 2006-03-06 | 2006-03-17 | 7 | 96d |  | start no earlier than 2006-03-01 | SISL 11 | 80h |
| 39 | 3.1.9 | **Contact list and menu options (Without functionality inside) after pressing Contact hard key** |  | 15d | 2006-03-06 | 2006-03-24 |  | 56d |  |  |  | 400h |
| 40 | 3.1.9.1 | list address book |  | 2w | 2006-03-06 | 2006-03-17 | 7 | 96d |  |  | BJ 1; BJ 2 | 160h |
| 41 | 3.1.9.2 | display menu options with some functions, e.g. copy, delete, add |  | 3w | 2006-03-06 | 2006-03-24 | 7 | 56d | 0d |  | BJ 1; BJ 2 | 240h |
| 42 | 3.1.10 | **Remove or disable or hide features** |  | 5d | 2006-02-22 | 2006-02-28 |  | 109d |  |  |  |  |
| 43 | 3.1.10.1 | Java (remove) |  | 1w | 2006-02-22 | 2006-02-28 | 9 | 109d |  | start no earlier than 2006-02-20 |  |  |
| 44 | 3.1.11 | Development test and Sprint 1 ST |  | 0.6w? | 2006-03-29 | 2006-03-31 |  | 86d | 0d | finish no earlier than 2006-03-31 |  |  |
| 45 | 3.2 | **Feature Sprint 2** |  | 40d? | 2006-03-06 | 2006-04-28 |  | 46d |  |  |  | 3200h |
| 46 | 3.2.1 | Tips including sub-menus |  | 4w | 2006-03-27 | 2006-04-21 | 4 | 71d |  | start no earlier than 2006-03-27 | SISL 1; SISL 2 | 320h |
| 47 | 3.2.2 | **Startup Assistant** |  | 5d | 2006-04-03 | 2006-04-07 |  | 81d |  |  |  |  |
| 48 | 3.2.2.1 | Enter own number |  | 1w | 2006-04-03 | 2006-04-07 | 4 | 81d |  | start no earlier than 2006-04-03 |  |  |
| 49 | 3.2.3 | **Start-up/power on dialogs** |  | 0d | 2006-04-28 | 2006-04-28 |  | 66d |  |  |  |  |
| 50 | 3.2.3.1 | date and time setup (covered by Sprint 2 - Settings) | milestone | 0w | 2006-04-28 | 2006-04-28 | 4 | 66d |  | finish no earlier than 2006-04-28 |  |  |

Notes:
- 26: Refer to Vodafone Simply styleguide page5 1.idle, including all functional scenario, w/o transition, headline, softkeys effect
- 28: invoke of native appl of hard keys, light effect at home space
- 33: calling use case: call origination, termination, call setup
- 35: UIOS
- 46: Tips and sub-menu
- 49: pin iput, incl. error handling

| ID | WBS | Task | Duration | Start | Finish | Predecessors | Total slack | Free slack | Constraint | Resources | Work |
| --- | --- | --- | --- | --- | --- | --- | --- | --- | --- | --- | --- |
| 51 | 3.2.4 | **Idle screen** | 20d | 2006-03-29 | 2006-04-25 |  | 69d |  |  |  |  |
| 52 | 3.2.4.1 | Idle UI adaption on network selection | 2w | 2006-04-03 | 2006-04-14 |  | 76d |  | start no earlier than 2006-04-03 |  |  |
| 53 | 3.2.4.2 | show call setting: call barring incoming/outcoming if abroad (new ), effect in Idle | 4w | 2006-03-29 | 2006-04-25 |  | 69d |  | start no earlier than 2006-03-29 |  |  |
| 54 | 3.2.5 | **Contact list and menu options (Without functionality inside) after pressing Contact hard key** | 20d | 2006-03-27 | 2006-04-21 |  | 71d |  |  |  | 960h |
| 55 | 3.2.5.1 | contact editor | 4w | 2006-03-27 | 2006-04-21 | 41 | 71d |  |  | BJ 1 | 160h |
| 56 | 3.2.5.2 | merge entry in sim to contact list | 4w | 2006-03-27 | 2006-04-21 | 41 | 71d |  |  | BJ 1 | 160h |
| 57 | 3.2.5.3 | complicated functions: add reminder, sim backup w/o view log | 4w | 2006-03-27 | 2006-04-21 | 41 | 71d |  |  | BJ 1; BJ 2 | 320h |
| 58 | 3.2.5.4 | call record look and feel | 4w | 2006-03-27 | 2006-04-21 | 41 | 71d |  |  | BJ 1; BJ 2 | 320h |
| 59 | 3.2.6 | **Screen transitions (Sliding effect)** | 20d | 2006-03-22 | 2006-04-18 |  | 34d |  |  |  | 320h |
| 60 | 3.2.6.1 | sliding effect | 4w | 2006-03-22 | 2006-04-18 | 37 | 34d | 3d |  | BJ 1; BJ 2 | 320h |
| 61 | 3.2.7 | **Volume side key, Ringer side key and lock key invocation** | 20d | 2006-03-20 | 2006-04-14 |  | 76d |  |  |  | 160h |
| 62 | 3.2.7.1 | ringer side key in idle | 2w | 2006-03-20 | 2006-03-31 | 23 | 76d | 0d | start no earlier than 2006-03-20 | SISL 7 | 80h |
| 63 | 3.2.7.2 | volume side key in call | 1w | 2006-04-03 | 2006-04-07 | 62 | 76d | 0d |  | SISL 7 | 40h |
| 64 | 3.2.7.3 | lock key | 1w | 2006-04-10 | 2006-04-14 | 63 | 76d |  |  | SISL 7 | 40h |
| 65 | 3.2.8 | **Synchronization including remote sync and sync with SIM** | 25d | 2006-03-06 | 2006-04-07 |  | 76d |  |  |  | 720h |
| 66 | 3.2.8.1 | SyncML UI adaption | 4w | 2006-03-06 | 2006-03-31 | 9 | 81d | 5d | start no earlier than 2006-03-06 | PSE NJ 1; PSE NJ 2 | 320h |
| 67 | 3.2.8.2 | SyncML workflow adaption | 5w | 2006-03-06 | 2006-04-07 | 9 | 76d | 0d | start no earlier than 2006-03-06 | PSE NJ 2; PSE NJ 1 | 400h |
| 68 | 3.2.9 | **Settings** | 15d | 2006-04-03 | 2006-04-21 |  | 56d |  |  |  | 240h |
| 69 | 3.2.9.1 | ring tong, keypad tone, time/date | 3w | 2006-04-03 | 2006-04-21 |  | 56d | 0d | start no earlier than 2006-04-03 | SISL 3; SISL 4 | 240h |
| 70 | 3.2.9.2 | display my number, language, change PIN | 3w | 2006-04-03 | 2006-04-21 |  | 56d | 0d | start no earlier than 2006-04-03 |  |  |
| 71 | 3.2.10 | Unified Inbox (Layout) | 2w | 2006-04-03 | 2006-04-14 | 37 | 76d |  | start no earlier than 2006-04-03 | SISL 14 | 80h |
| 72 | 3.2.11 | Templates/Drafts | 4w | 2006-03-27 | 2006-04-21 |  | 71d |  | start no earlier than 2006-03-27 |  |  |
| 73 | 3.2.12 | **View contact log** | 20d | 2006-03-27 | 2006-04-21 |  | 56d |  |  |  | 320h |
| 74 | 3.2.12.1 | new msg info table support in PIM AE | 4w | 2006-03-27 | 2006-04-21 | 41 | 71d |  | start no earlier than 2006-02-20 |  |  |
| 75 | 3.2.12.2 | sorting mechanism | 4w | 2006-03-27 | 2006-04-21 | 41 | 71d |  | start no earlier than 2006-02-20 |  |  |
| 76 | 3.2.12.3 | UI implementation in PIM | 4w | 2006-03-27 | 2006-04-21 | 41 | 71d |  | start no earlier than 2006-02-20 |  |  |
| 77 | 3.2.12.4 | export inteface (insert contact, select contact) to external appl. i.e. messaging, IDC | 4w | 2006-03-27 | 2006-04-21 | 41 | 56d | 0d | start no earlier than 2006-03-27 | BJ 1; BJ 2 | 320h |
| 78 | 3.2.12.5 | call record adaption | 4w | 2006-03-27 | 2006-04-21 | 41 | 71d |  | start no earlier than 2006-02-20 |  |  |

Notes:
- 51: Refer to Vodafone Simply styleguide page5 1.idle, including all functional scenario, w/o transition, headline, softkeys effect
- 71: Jerry look and feel of Unified inbox in SGL functionality w/o MMS

| ID | WBS | Task | Duration | Start | Finish | Predecessors | Total slack | Free slack | Constraint | Resources | Work |
| --- | --- | --- | --- | --- | --- | --- | --- | --- | --- | --- | --- |
| 79 | 3.2.13 | **Remove or disable or hide features** | 20d | 2006-03-27 | 2006-04-21 |  | 71d |  |  |  |  |
| 80 | 3.2.13.1 | Irda, BT (remove) | 2w | 2006-04-03 | 2006-04-14 |  | 76d |  | start no earlier than 2006-04-03 |  |  |
| 81 | 3.2.13.2 | Camera (remove) | 2w | 2006-04-03 | 2006-04-14 |  | 76d |  | start no earlier than 2006-04-03 |  |  |
| 82 | 3.2.13.3 | Browser (hide) | 4w | 2006-03-27 | 2006-04-21 |  | 71d |  | start no earlier than 2006-03-27 |  |  |
| 83 | 3.2.13.4 | showing UI notification about accessory from connectivity (disable) | 2w | 2006-04-03 | 2006-04-14 |  | 76d |  | start no earlier than 2006-04-03 |  |  |
| 84 | 3.2.14 | customization | 2w | 2006-04-10 | 2006-04-21 |  | 71d |  | start no earlier than 2006-04-10 | BJ 1 | 80h |
| 85 | 3.2.15 | Development test and Sprint 2 ST | 0.8w? | 2006-04-25 | 2006-04-28 |  | 66d | 0d | start no earlier than 2006-04-25 |  |  |
| 86 | 3.3 | **Feature Sprint 3** | 53d? | 2006-03-20 | 2006-05-31 |  | 43d |  |  |  | 1040h |
| 87 | 3.3.1 | Key lock screen after switching the key lock hard key. | 4w | 2006-04-24 | 2006-05-19 | 3, 60 | 51d |  | start no earlier than 2006-04-24 | SISL 1 | 160h |
| 88 | 3.3.2 | Inbox UI (all message list) | 5w | 2006-03-27 | 2006-04-28 |  | 66d |  | start no earlier than 2006-03-27 |  |  |
| 89 | 3.3.3 | Settings complete | 3w | 2006-04-24 | 2006-05-12 | 69, 70 | 56d |  | start no earlier than 2006-04-03 |  |  |
| 90 | 3.3.4 | **Startup Assistant** | 30d | 2006-04-10 | 2006-05-19 |  | 51d |  |  |  |  |
| 91 | 3.3.4.1 | SyncML invocation | 1w | 2006-04-10 | 2006-04-14 | 66, 67 | 76d |  |  |  |  |
| 92 | 3.3.4.2 | **Idle screen** | 10d | 2006-05-08 | 2006-05-19 |  | 51d |  |  |  |  |
| 93 | 3.3.4.2.1 | new event dialog (part of Unified Inbox) | 2w | 2006-05-08 | 2006-05-19 |  | 51d |  | start no earlier than 2006-05-08 |  |  |
| 94 | 3.3.5 | **Voice call screens full function** | 20d | 2006-04-24 | 2006-05-19 | 3 | 51d |  |  |  |  |
| 95 | 3.3.5.1 | all call list | 2w | 2006-05-08 | 2006-05-19 |  | 51d |  | start no earlier than 2006-05-08 |  |  |
| 96 | 3.3.5.2 | handling different network release codes | 4w | 2006-04-24 | 2006-05-19 |  | 51d |  | start no earlier than 2006-04-24 |  |  |
| 97 | 3.3.5.3 | call reminder | 4w | 2006-04-24 | 2006-05-19 |  | 51d |  | start no earlier than 2006-04-24 |  |  |
| 98 | 3.3.5.4 | in-call menu adaption | 2w | 2006-05-08 | 2006-05-19 |  | 51d |  | start no earlier than 2006-05-08 |  |  |
| 99 | 3.3.6 | **Voice messaging** | 45d | 2006-03-20 | 2006-05-19 |  | 51d |  |  |  |  |
| 100 | 3.3.6.1 | view and editor | 9w | 2006-03-20 | 2006-05-19 |  | 51d |  | start no earlier than 2006-03-20 |  |  |
| 101 | 3.3.6.2 | send and receive | 2w | 2006-05-08 | 2006-05-19 |  | 51d |  | start no earlier than 2006-05-08 |  |  |
| 102 | 3.3.7 | **MsgAE** | 25d | 2006-04-10 | 2006-05-12 |  | 56d |  |  |  |  |
| 103 | 3.3.7.1 | get and update msg table from inbox UI/sent msg UI | 4w | 2006-04-10 | 2006-05-05 |  | 61d |  | start no earlier than 2006-04-10 |  |  |
| 104 | 3.3.7.2 | delete msg and delete all | 4w | 2006-04-17 | 2006-05-12 |  | 56d |  | start no earlier than 2006-04-17 |  |  |
| 105 | 3.3.7.3 | SMS/MMS client updation | 2w | 2006-05-01 | 2006-05-12 |  | 56d |  | start no earlier than 2006-05-01 |  |  |
| 106 | 3.3.8 | Picture messaging | 4w | 2006-04-24 | 2006-05-19 |  | 51d |  | start no earlier than 2006-04-24 |  |  |
| 107 | 3.3.9 | Message Setting | 3w | 2006-04-24 | 2006-05-12 |  | 56d |  | start no earlier than 2006-04-24 |  |  |

Notes:
- 87: implementation of keylock screen
- 92: Refer to Vodafone Simply styleguide page5 1.idle, including all functional scenario, w/o transition, headline, softkeys effect

| ID | WBS | Task | Duration | Start | Finish | Predecessors | Total slack | Free slack | Constraint | Resources | Work |
| --- | --- | --- | --- | --- | --- | --- | --- | --- | --- | --- | --- |
| 108 | 3.3.10 | **Menu look and feel - full compliance** | 40d | 2006-03-27 | 2006-05-19 |  | 51d |  |  |  |  |
| 109 | 3.3.10.1 | UIOS full compliance (incl. progress bar) | 3w | 2006-03-27 | 2006-04-14 | 37 | 56d | 5d | start no earlier than 2006-03-27 |  |  |
| 110 | 3.3.10.2 | VF menu full compliance (incl. progress bar) | 4w | 2006-04-24 | 2006-05-19 | 109 | 51d |  | start no earlier than 2006-04-24 |  |  |
| 111 | 3.3.11 | **Contact list and menu options (Without functionality inside) after pressing Contact hard key** | 15d | 2006-04-24 | 2006-05-12 |  | 56d |  |  |  | 160h |
| 112 | 3.3.11.1 | launch external appl., e.g. mms, sms, call | 2w | 2006-04-24 | 2006-05-05 |  | 61d |  | start no earlier than 2006-04-24 | BJ 1 | 80h |
| 113 | 3.3.11.2 | PIM settings | 2w | 2006-05-01 | 2006-05-12 |  | 56d |  | start no earlier than 2006-05-01 | BJ 1 | 80h |
| 114 | 3.3.12 | **Screen transitions (Sliding effect)** | 20d | 2006-04-24 | 2006-05-19 |  | 31d |  |  |  | 640h |
| 115 | 3.3.12.1 | menu selection transition | 4w | 2006-04-24 | 2006-05-19 | 60 | 31d | 0d | start no earlier than 2006-04-24 | BJ 1; BJ 2 | 320h |
| 116 | 3.3.12.2 | popup transition | 4w | 2006-04-24 | 2006-05-19 | 60 | 31d | 0d | start no earlier than 2006-04-24 | BJ 1; BJ 2 | 320h |
| 117 | 3.3.13 | **View contact log** | 10d | 2006-04-24 | 2006-05-05 |  | 61d |  |  |  |  |
| 118 | 3.3.13.1 | adaption in messaging | 2w | 2006-04-24 | 2006-05-05 | 77 | 61d |  | start no earlier than 2006-02-20 |  |  |
| 119 | 3.3.14 | **Remove or disable or hide features** | 20d | 2006-04-24 | 2006-05-19 |  | 51d |  |  |  |  |
| 120 | 3.3.14.1 | MM removing | 2w | 2006-05-08 | 2006-05-19 |  | 51d |  | start no earlier than 2006-05-08 |  |  |
| 121 | 3.3.14.2 | DRM (disable) | 4w | 2006-04-24 | 2006-05-19 |  | 51d |  | start no earlier than 2006-04-24 |  |  |
| 122 | 3.3.15 | **VF Simply Alarm Clock** | 20d | 2006-04-24 | 2006-05-19 |  | 51d |  |  |  |  |
| 123 | 3.3.15.1 | list all alarm events | 4w | 2006-04-24 | 2006-05-19 |  | 51d |  | start no earlier than 2006-04-24 |  |  |
| 124 | 3.3.16 | customization | 2w | 2006-05-12 | 2006-05-25 |  | 43d | 0d | start no earlier than 2006-05-12 | BJ 1 | 80h |
| 125 | 3.3.17 | Development test and Sprint 3 ST | 0.8w? | 2006-05-26 | 2006-05-31 | 124 | 43d | 0d | finish no earlier than 2006-05-31 |  |  |
| 126 | 3.4 | **Feature Sprint 4** | 73d | 2006-03-20 | 2006-06-28 |  | 23d |  |  |  | 560h |
| 127 | 3.4.1 | Idle split screen | 4w | 2006-06-01 | 2006-06-28 |  | 23d |  | start no earlier than 2006-06-01 |  |  |
| 128 | 3.4.2 | **Idle screen** | 60d | 2006-03-20 | 2006-06-09 |  | 36d |  |  |  |  |
| 129 | 3.4.2.1 | Welcome tour | 1w | 2006-06-05 | 2006-06-09 |  | 36d |  | start no earlier than 2006-06-05 |  |  |
| 130 | 3.4.2.2 | Charging display adaption | 1w | 2006-06-05 | 2006-06-09 |  | 36d |  | start no earlier than 2006-06-05 |  |  |
| 131 | 3.4.2.3 | **Interruption by Events** | 49d | 2006-03-20 | 2006-05-25 |  | 47d |  |  |  |  |
| 132 | 3.4.2.3.1 | Separation of Call functionality from the Idle | 6w | 2006-03-20 | 2006-04-28 |  | 66d |  | start no earlier than 2006-03-20 |  |  |
| 133 | 3.4.2.3.2 | Call CSM Message Handling | 6w | 2006-04-10 | 2006-05-19 |  | 51d |  | start no earlier than 2006-04-10 |  |  |
| 134 | 3.4.2.3.3 | Dial Dialog Updation Handling | 4w | 2006-04-28 | 2006-05-25 |  | 47d |  | start no earlier than 2006-04-28 |  |  |

Notes:
- 128: Refer to Vodafone Simply styleguide page5 1.idle, including all functional scenario, w/o transition, headline, softkeys effect

| ID | WBS | Task | Duration | Start | Finish | Predecessors | Total slack | Free slack | Constraint | Resources | Work |
| --- | --- | --- | --- | --- | --- | --- | --- | --- | --- | --- | --- |
| 135 | 3.4.3 | **Sleep mode with timer settings** | 25d | 2006-05-22 | 2006-06-23 | 3 | 26d |  |  |  |  |
| 136 | 3.4.3.1 | back to last screen | 4w | 2006-05-22 | 2006-06-16 |  | 31d |  | start no earlier than 2006-05-22 |  |  |
| 137 | 3.4.3.2 | screen saver handling in idle | 2w | 2006-06-12 | 2006-06-23 |  | 26d |  | start no earlier than 2006-06-12 |  |  |
| 138 | 3.4.4 | **Text Message (SMS)** | 28d | 2006-05-08 | 2006-06-14 |  | 33d |  |  |  |  |
| 139 | 3.4.4.1 | view and editor | 5w | 2006-05-08 | 2006-06-09 |  | 36d |  | start no earlier than 2006-05-08 |  |  |
| 140 | 3.4.4.2 | send and receive | 2w | 2006-06-01 | 2006-06-14 |  | 33d |  | start no earlier than 2006-06-01 |  |  |
| 141 | 3.4.5 | **hover functionality in Contact list** | 20d | 2006-05-22 | 2006-06-16 | 3 | 31d |  |  |  | 80h |
| 142 | 3.4.5.1 | Implementation by UIOS | 2w | 2006-05-22 | 2006-06-02 | 115, 116 | 31d | 0d |  | SISL 11 | 80h |
| 143 | 3.4.5.2 | PIM Adaption | 2w | 2006-06-05 | 2006-06-16 | 142 | 31d |  |  |  |  |
| 144 | 3.4.5.3 | messaging adaption | 2w | 2006-06-05 | 2006-06-16 | 142 | 31d |  |  |  |  |
| 145 | 3.4.6 | **VF Simply Alarm Clock** | 15d | 2006-05-29 | 2006-06-16 |  | 31d |  |  |  |  |
| 146 | 3.4.6.1 | time/date editor | 2w | 2006-05-29 | 2006-06-09 |  | 36d |  | start no earlier than 2006-05-29 |  |  |
| 147 | 3.4.6.2 | alarm text | 1w | 2006-05-29 | 2006-06-02 |  | 41d |  | start no earlier than 2006-05-29 |  |  |
| 148 | 3.4.6.3 | alarm tone/volume/vibration | 3w | 2006-05-29 | 2006-06-16 |  | 31d |  | start no earlier than 2006-05-29 |  |  |
| 149 | 3.4.6.4 | menu options in alarm clock, i.e. delete, add | 2w | 2006-06-01 | 2006-06-14 |  | 33d |  | start no earlier than 2006-06-01 |  |  |
| 150 | 3.4.7 | Unified Inbox Functionality | 6w | 2006-05-01 | 2006-06-09 |  | 36d |  | start no earlier than 2006-05-01 | SISL 17; SISL 18 | 480h |
| 151 | 3.4.8 | Unified sent message | 3w | 2006-05-29 | 2006-06-16 |  | 31d |  | start no earlier than 2006-05-29 |  |  |
| 152 | 3.4.9 | Delete (All) wizard | 4w | 2006-05-29 | 2006-06-23 |  | 26d |  | start no earlier than 2006-05-29 |  |  |
| 153 | 3.4.10 | **MsgAE** | 15d | 2006-06-01 | 2006-06-21 |  | 28d |  |  |  |  |
| 154 | 3.4.10.1 | Sync between message table in PIM and message DB in AppMsg | 3w | 2006-06-01 | 2006-06-21 | 77 | 28d |  | start no earlier than 2006-06-01 |  |  |
| 155 | 3.5 | customization | 3w | 2006-06-05 | 2006-06-23 |  | 21d | 5d | start no earlier than 2006-06-05 | BJ 1 | 120h |
| 156 | 3.6 | Development test and Sprint 4 ST | 1w? | 2006-07-03 | 2006-07-07 | 155 | 16d | 0d | finish no earlier than 2006-07-07 |  |  |
| 157 | 3.7 | S25 SW bugfix | 4w? | 2006-07-03 | 2006-07-28 |  | 1d |  | start no earlier than 2006-07-03 |  |  |
| 158 | 4 | **System Test** | 15d | 2006-07-03 | 2006-07-21 |  | 6d |  |  |  |  |
| 159 | 4.1 | 1st full run | 3w | 2006-07-03 | 2006-07-21 |  | 6d |  | finish no earlier than 2006-07-21 |  |  |

Notes:
- 135: After the sleep mode deactivation, the user returns to the same screen from where the sleep mode was activated.
